# Új utazási program bevezetése

How a schedule from MS Project changed from version to version. A marks actual dates.

## Version 1 (data date 2005-02-22, saved 2009-04-14, file Follow me - Nyomonk�vet�s 2005febr22.mpp)

| ID | WBS | Task | Duration | Start | Finish | Predecessors | Complete | Total float |
| --- | --- | --- | --- | --- | --- | --- | --- | --- |
| 1 | 1 | **I. szakasz - Előkészületek** | 23d | 2004-11-11 A | 2004-12-13 A |  | 100% |  |
| 2 |  | Az előkészületek szakasz kezdete | 0d | 2004-11-11 A | 2004-11-11 A |  | 100% |  |
| 3 |  | Az indokoltság kiértékelése | 12d | 2004-11-11 A | 2004-11-26 A | 2 | 100% |  |
| 4 | 1.3 | **Ötletterv** | 3d | 2004-11-29 A | 2004-12-01 A |  | 100% |  |
| 5 |  | Az elvárások pontosítása | 3d | 2004-11-29 A | 2004-12-01 A | 3 | 100% |  |
| 6 | 1.4 | **Az alapok kidolgozása** | 7d | 2004-12-03 A | 2004-12-13 A |  | 100% |  |
| 7 |  | A célok meghatározása | 3d | 2004-12-03 A | 2004-12-07 A | 5 | 100% |  |
| 8 |  | A kritériumok meghatározása | 2d | 2004-12-08 A | 2004-12-09 A | 7 | 100% |  |
| 9 |  | A terjedelem meghatározása | 2d | 2004-12-10 A | 2004-12-13 A | 8 | 100% |  |
| 10 |  | Az előkészületek szakasz vége | 0d | 2004-12-13 A | 2004-12-13 A | 9 | 100% |  |
| 11 | 2 | **II. szakasz Logisztika** | 45d | 2004-12-13 A | 2005-02-18 A |  | 100% |  |
| 12 |  | A logisztika szakasz kezdete | 0d | 2004-12-13 A | 2004-12-13 A | 10 | 100% |  |
| 13 |  | Kapcsolat felvétele a nagykövetségekkel | 1d | 2004-12-14 A | 2004-12-14 A | 9, 12 | 100% |  |
| 14 | 2.3 | **Szállodák felderítése** | 20d | 2004-12-15 A | 2005-01-13 A |  | 100% |  |
| 15 |  | Információk gyűjtése a szállodákról | 12d | 2004-12-15 A | 2004-12-30 A | 13 | 100% |  |
| 16 |  | A számításba jövő szállodák kiválasztása | 8d | 2004-12-31 A | 2005-01-13 A | 15 | 100% |  |
| 17 |  | Kapcsolatok felvétele a szállodákkal | 5d | 2005-01-06 A | 2005-01-13 A | 16SS+3d | 100% |  |
| 18 | 2.4 | **Szállítóvállalat felderítése** | 6d | 2005-01-14 A | 2005-01-24 A |  | 100% |  |
| 19 |  | Információk gyűjtése a szállítókról | 3d | 2005-01-14 A | 2005-01-18 A | 17 | 100% |  |
| 20 |  | A szállító kiválasztása | 2d | 2005-01-19 A | 2005-01-21 A | 19 | 100% |  |
| 21 |  | Kapcsolat felvétele a szállítóval | 1d | 2005-01-24 A | 2005-01-24 A | 20SS+2d | 100% |  |
| 22 |  | Vízumok beszerzése | 6d | 2005-01-25 A | 2005-02-01 A | 21 | 100% |  |
| 23 | 2.6 | **Szállodák biztosítása** | 8d | 2005-02-02 A | 2005-02-11 A |  | 100% |  |
| 24 |  | Helyfoglalás | 6d | 2005-02-02 A | 2005-02-09 A | 22 | 100% |  |
| 25 |  | Szerződéskötés | 2d | 2005-02-10 A | 2005-02-11 A | 24 | 100% |  |
| 26 | 2.7 | **Szállító biztosítása** | 4d | 2005-02-14 A | 2005-02-18 A |  | 100% |  |
| 27 |  | Rezerválás | 3d | 2005-02-14 A | 2005-02-17 A | 25 | 100% |  |
| 28 |  | Szerződéskötés | 1d | 2005-02-18 A | 2005-02-18 A | 27 | 100% |  |
| 29 |  | A Logisztika szakasz vége | 0d | 2005-02-18 A | 2005-02-18 A | 28 | 100% |  |
| 30 | 3 | **III. szakasz Programkészítés** | 15d | 2005-02-18 A | 2005-03-11 |  | 11% | 69d |
| 31 |  | A Programkészítés szakasz kezdete | 0d | 2005-02-18 A | 2005-02-18 A | 29 | 100% |  |
| 32 |  | Az utazás időpontjának kijelölése | 6d | 2005-02-21 A | 2005-02-28 | 28, 31 | 33% | 78d |
| 33 |  | Az útvezető kinevezése | 9d | 2005-02-22 A | 2005-03-04 | 32SS+1d | 11% | 0d |
| 34 |  | Szabad programok meghatározása | 8d | 2005-02-23 | 2005-03-04 | 32SS+2d, 33FF |  | 0d |
| 35 |  | Személyzet biztosítása | 5d | 2005-03-07 | 2005-03-11 | 34 |  | 0d |
| 36 |  | A Programkészítés szakasz vége | 0d | 2005-03-11 | 2005-03-11 | 35 |  | 7d |
| 37 | 4 | **IV. szakasz Végrehajtás** | 152d? | 2004-11-11 | 2005-06-10 |  |  | 0d |
| 38 |  | A végrehajtás szakasz kezdete | 0d | 2005-03-11 | 2005-03-11 | 36 |  | 7d |
| 39 | 4.2 | **Az új utazási program piacra dobása** | 116d? | 2004-11-11 | 2005-04-27 |  |  | 36d |
| 40 |  | A marketing stratégia kialakítása | 1d? | 2004-11-11 | 2004-11-11 |  |  | 151d |
| 41 |  | Reklámanyag készítése | 5d | 2005-03-23 | 2005-03-29 | 35FS+7d, 38 |  | 0d |
| 42 |  | A marketing stratégia kivitelezése | 20d | 2005-03-30 | 2005-04-26 | 41 |  | 0d |
| 43 |  | Bemutató tevékenységek | 15d | 2005-04-06 | 2005-04-26 | 42FF |  | 0d |
| 44 |  | Az érdekeltek kikérdezése | 1d | 2005-04-27 | 2005-04-27 | 43 |  | 0d |
| 45 | 4.3 | **Az új utazási program kivitelezése** | 25d | 2005-04-28 | 2005-05-26 |  |  | 0d |
| 46 |  | Az utasok nyilvántartásba vétele | 1d | 2005-04-28 | 2005-04-28 | 44 |  | 0d |
| 47 |  | Az indulás megszervezése | 5d | 2005-04-29 | 2005-05-03 | 46 |  | 0d |
| 48 |  | A jóváhagyott terv végrehajtása | 15d | 2005-05-04 | 2005-05-20 | 47 |  | 0d |
| 49 |  | A visszautazással kapcsolatos kötelezettségek rendezése | 3d | 2005-05-24 | 2005-05-26 | 48FS+1d |  | 0d |
| 50 | 4.4 | **Operatív jelentések készítése** | 6d | 2005-06-03 | 2005-06-10 |  |  | 0d |
| 51 |  | Az eredemények együttes megjelenítése | 5d | 2005-06-03 | 2005-06-09 | 49FS+5d |  | 0d |
| 52 |  | A dokumentáció átadása | 1d | 2005-06-10 | 2005-06-10 | 51 |  | 0d |
| 53 |  | A Véhgrehajtás szakasz befejezése | 0d | 2005-06-10 | 2005-06-10 | 52 |  | 0d |

## Version 2 (saved 2009-04-14, file Follow me - B�zisterv.mpp)

Last finish 2005-06-10 → 2005-05-31 (-10d). Complete tasks 22 → 0.

Changed:

| ID | Task | Start | Finish | Duration | Complete | Total float | Other |
| --- | --- | --- | --- | --- | --- | --- | --- |
| 1 | **I. szakasz Előkészületek** | 2004-11-11 A → 2004-11-11 | 2004-12-13 A → 2004-12-03 (-10d) | 23d → 17d | 100% → 0% | none → 0d | was named I. szakasz - Előkészületek |
| 2 | Az előkészületek szakasz kezdete | 2004-11-11 A → 2004-11-11 | 2004-11-11 A → 2004-11-11 |  | 100% → 0% | none → 0d |  |
| 3 | Az indokoltság kiértékelése | 2004-11-11 A → 2004-11-11 | 2004-11-26 A → 2004-11-22 (-4d) | 12d → 8d | 100% → 0% | none → 0d |  |
| 4 | **Ötletterv** | 2004-11-29 A → 2004-11-23 (-6d) | 2004-12-01 A → 2004-11-25 (-6d) |  | 100% → 0% | none → 0d |  |
| 5 | Az elvárások pontosítása | 2004-11-29 A → 2004-11-23 (-6d) | 2004-12-01 A → 2004-11-25 (-6d) |  | 100% → 0% | none → 0d |  |
| 6 | **Az alapok kidolgozása** | 2004-12-03 A → 2004-11-26 (-7d) | 2004-12-13 A → 2004-12-03 (-10d) | 7d → 6d | 100% → 0% | none → 0d |  |
| 7 | A célok meghatározása | 2004-12-03 A → 2004-11-26 (-7d) | 2004-12-07 A → 2004-11-29 (-8d) | 3d → 2d | 100% → 0% | none → 0d |  |
| 8 | A kritériumok meghatározása | 2004-12-08 A → 2004-11-30 (-8d) | 2004-12-09 A → 2004-12-01 (-8d) |  | 100% → 0% | none → 0d |  |
| 9 | A terjedelem meghatározása | 2004-12-10 A → 2004-12-02 (-8d) | 2004-12-13 A → 2004-12-03 (-10d) |  | 100% → 0% | none → 0d |  |
| 10 | Az előkészületek szakasz vége | 2004-12-13 A → 2004-12-03 (-10d) | 2004-12-13 A → 2004-12-03 (-10d) |  | 100% → 0% | none → 0d |  |
| 11 | **II. szakasz Logisztika** | 2004-12-13 A → 2004-12-03 (-10d) | 2005-02-18 A → 2005-02-07 (-11d) | 45d → 43d | 100% → 0% | none → 0d |  |
| 12 | A logisztika szakasz kezdete | 2004-12-13 A → 2004-12-03 (-10d) | 2004-12-13 A → 2004-12-03 (-10d) |  | 100% → 0% | none → 0d |  |
| 13 | Kapcsolat felvétele a nagykövetségekkel | 2004-12-14 A → 2004-12-06 (-8d) | 2004-12-14 A → 2004-12-06 (-8d) |  | 100% → 0% | none → 0d |  |
| 14 | **Szállodák felderítése** | 2004-12-15 A → 2004-12-07 (-8d) | 2005-01-13 A → 2004-12-30 (-14d) | 20d → 18d | 100% → 0% | none → 0d |  |
| 15 | Információk gyűjtése a szállodákról | 2004-12-15 A → 2004-12-07 (-8d) | 2004-12-30 A → 2004-12-20 (-10d) | 12d → 10d | 100% → 0% | none → 0d |  |
| 16 | A számításba jövő szállodák kiválasztása | 2004-12-31 A → 2004-12-21 (-10d) | 2005-01-13 A → 2004-12-30 (-14d) |  | 100% → 0% | none → 0d |  |
| 17 | Kapcsolatok felvétele a szállodákkal | 2005-01-06 A → 2004-12-24 (-13d) | 2005-01-13 A → 2004-12-30 (-14d) |  | 100% → 0% | none → 0d |  |
| 18 | **Szállítóvállalat felderítése** | 2005-01-14 A → 2004-12-31 (-14d) | 2005-01-24 A → 2005-01-11 (-13d) |  | 100% → 0% | none → 0d |  |
| 19 | Információk gyűjtése a szállítókról | 2005-01-14 A → 2004-12-31 (-14d) | 2005-01-18 A → 2005-01-05 (-13d) |  | 100% → 0% | none → 0d |  |
| 20 | A szállító kiválasztása | 2005-01-19 A → 2005-01-06 (-13d) | 2005-01-21 A → 2005-01-10 (-11d) |  | 100% → 0% | none → 0d |  |
| 21 | Kapcsolat felvétele a szállítóval | 2005-01-24 A → 2005-01-11 (-13d) | 2005-01-24 A → 2005-01-11 (-13d) |  | 100% → 0% | none → 0d |  |
| 22 | Vízumok beszerzése | 2005-01-25 A → 2005-01-12 (-13d) | 2005-02-01 A → 2005-01-19 (-13d) |  | 100% → 0% | none → 0d |  |
| 23 | **Szállodák biztosítása** | 2005-02-02 A → 2005-01-21 (-12d) | 2005-02-11 A → 2005-02-01 (-10d) |  | 100% → 0% | none → 0d |  |
| 24 | Helyfoglalás | 2005-02-02 A → 2005-01-21 (-12d) | 2005-02-09 A → 2005-01-28 (-12d) |  | 100% → 0% | none → 0d |  |
| 25 | Szerződéskötés | 2005-02-10 A → 2005-01-31 (-10d) | 2005-02-11 A → 2005-02-01 (-10d) |  | 100% → 0% | none → 0d |  |
| 26 | **Szállító biztosítása** | 2005-02-14 A → 2005-02-02 (-12d) | 2005-02-18 A → 2005-02-07 (-11d) |  | 100% → 0% | none → 0d |  |
| 27 | Rezerválás | 2005-02-14 A → 2005-02-02 (-12d) | 2005-02-17 A → 2005-02-04 (-13d) |  | 100% → 0% | none → 0d |  |
| 28 | Szerződéskötés | 2005-02-18 A → 2005-02-07 (-11d) | 2005-02-18 A → 2005-02-07 (-11d) |  | 100% → 0% | none → 0d |  |
| 29 | A Logisztika szakasz vége | 2005-02-18 A → 2005-02-07 (-11d) | 2005-02-18 A → 2005-02-07 (-11d) |  | 100% → 0% | none → 0d |  |
| 30 | **III. szakasz Programkészítés** | 2005-02-18 A → 2005-02-07 (-11d) | 2005-03-11 → 2005-03-01 (-10d) |  | 11% → 0% | 69d → 0d |  |
| 31 | A Programkészítés szakasz kezdete | 2005-02-18 A → 2005-02-07 (-11d) | 2005-02-18 A → 2005-02-07 (-11d) |  | 100% → 0% | none → 0d |  |
| 32 | Az utazás időpontjának kijelölése | 2005-02-21 A → 2005-02-08 (-13d) | 2005-02-28 → 2005-02-16 (-12d) |  | 33% → 0% | 78d → 0d |  |
| 33 | Az útvezető kinevezése | 2005-02-22 A → 2005-02-09 (-13d) | 2005-03-04 → 2005-02-22 (-10d) |  | 11% → 0% |  |  |
| 34 | Szabad programok meghatározása | 2005-02-23 → 2005-02-10 (-13d) | 2005-03-04 → 2005-02-22 (-10d) |  |  |  |  |
| 35 | Személyzet biztosítása | 2005-03-07 → 2005-02-23 (-12d) | 2005-03-11 → 2005-03-01 (-10d) |  |  |  |  |
| 36 | A Programkészítés szakasz vége | 2005-03-11 → 2005-03-01 (-10d) | 2005-03-11 → 2005-03-01 (-10d) |  |  |  |  |
| 37 | **IV. szakasz Végrehajtás** | 2004-11-11 → 2005-03-01 (+110d) | 2005-06-10 → 2005-05-31 (-10d) | 152d? → 69d |  |  |  |
| 38 | A végrehajtás szakasz kezdete | 2005-03-11 → 2005-03-01 (-10d) | 2005-03-11 → 2005-03-01 (-10d) |  |  |  |  |
| 39 | **Az új utazási program piacra dobása** | 2004-11-11 → 2005-03-11 (+120d) | 2005-04-27 → 2005-05-31 (+34d) | 116d? → 62d |  | 36d → 0d |  |
| 40 | **A marketing stratégia kialakítása** | 2004-11-11 → 2005-03-11 (+120d) | 2004-11-11 → 2005-04-15 (+155d) | 1d? → 26d |  | 151d → 0d |  |
| 41 | Reklámanyag készítése | 2005-03-23 → 2005-03-11 (-12d) | 2005-03-29 → 2005-03-17 (-12d) |  |  |  |  |
| 42 | A marketing stratégia kivitelezése | 2005-03-30 → 2005-03-18 (-12d) | 2005-04-26 → 2005-04-14 (-12d) |  |  |  |  |
| 43 | Bemutató tevékenységek | 2005-04-06 → 2005-03-25 (-12d) | 2005-04-26 → 2005-04-14 (-12d) |  |  |  |  |
| 44 | Az érdekeltek kikérdezése | 2005-04-27 → 2005-04-15 (-12d) | 2005-04-27 → 2005-04-15 (-12d) |  |  |  |  |
| 45 | **Az új utazási program kivitelezése** | 2005-04-28 → 2005-04-18 (-10d) | 2005-05-26 → 2005-05-16 (-10d) |  |  |  |  |
| 46 | Az utasok nyilvántartásba vétele | 2005-04-28 → 2005-04-18 (-10d) | 2005-04-28 → 2005-04-18 (-10d) |  |  |  |  |
| 47 | Az indulás megszervezése | 2005-04-29 → 2005-04-19 (-10d) | 2005-05-03 → 2005-04-25 (-8d) |  |  |  |  |
| 48 | A jóváhagyott terv végrehajtása | 2005-05-04 → 2005-04-26 (-8d) | 2005-05-20 → 2005-05-10 (-10d) |  |  |  |  |
| 49 | A visszautazással kapcsolatos kötelezettségek rendezése | 2005-05-24 → 2005-05-12 (-12d) | 2005-05-26 → 2005-05-16 (-10d) |  |  |  |  |
| 50 | **Operatív jelentések készítése** | 2005-06-03 → 2005-05-24 (-10d) | 2005-06-10 → 2005-05-31 (-10d) |  |  |  |  |
| 51 | Az eredemények együttes megjelenítése | 2005-06-03 → 2005-05-24 (-10d) | 2005-06-09 → 2005-05-30 (-10d) |  |  |  |  |
| 52 | A dokumentáció átadása | 2005-06-10 → 2005-05-31 (-10d) | 2005-06-10 → 2005-05-31 (-10d) |  |  |  |  |
| 53 | A Véhgrehajtás szakasz befejezése | 2005-06-10 → 2005-05-31 (-10d) | 2005-06-10 → 2005-05-31 (-10d) |  |  |  |  |
